# SureScripts Partner Implementation 110804

Schedule from MS Project, 2004-11-01 to 2005-04-11.
mindSHIFT

## Calendars

- Standard: Mon-Fri 08:00-12:00, 13:00-17:00; Sat-Sun off.

## Resources

| Resource |
| --- |
| SSS |
| Ptnr |

## Schedule

| ID | WBS | Task | Type | Duration | Start | Finish | Predecessors | Total slack | Free slack | Resources | Work |
| --- | --- | --- | --- | --- | --- | --- | --- | --- | --- | --- | --- |
| 1 | 1 | **SureScripts Implementation Project** |  | 116d | 2004-11-01 | 2005-04-11 |  | 0d |  |  | 2816h |
| 2 | 1.1 | **Initiation Phase** |  | 15d | 2004-11-01 | 2004-11-19 |  | 0d |  |  | 32h |
| 3 | 1.1.1 | NDA executed |  | 5d | 2004-11-01 | 2004-11-05 |  | 0d |  |  |  |
| 4 | 1.1.2 | Deliver implementation documentation |  | 1d | 2004-11-08 | 2004-11-08 | 3 | 0d |  | SSS | 8h |
| 5 | 1.1.3 | Contract ratified | milestone | 0d | 2004-11-08 | 2004-11-08 | 4 | 0d |  |  |  |
| 6 | 1.1.4 | **Project Planning** |  | 9d | 2004-11-09 | 2004-11-19 | 5 | 0d |  |  | 24h |
| 7 | 1.1.4.1 | Revise implementation template |  | 5d | 2004-11-09 | 2004-11-15 |  | 0d |  |  |  |
| 8 | 1.1.4.2 | Distribute for comment |  | 1d | 2004-11-16 | 2004-11-16 | 7 | 0d |  |  |  |
| 9 | 1.1.4.3 | Review/modify plan |  | 3d | 2004-11-17 | 2004-11-19 | 8 | 0d |  | SSS | 24h |
| 10 | 1.1.4.4 | Implementation plan complete | milestone | 0d | 2004-11-19 | 2004-11-19 | 9 | 0d |  |  |  |
| 11 | 1.2 | **Requirements & Analysis Phase** |  | 24d | 2004-11-22 | 2004-12-23 | 10 | 0d |  |  | 592h |
| 12 | 1.2.1 | Initial implementation call |  | 1d | 2004-11-22 | 2004-11-22 |  | 99d | 17d | SSS; Ptnr | 16h |
| 13 | 1.2.2 | **Connectivity Requirements** |  | 8d | 2004-11-22 | 2004-12-01 |  | 16d |  | SSS; Ptnr | 128h |
| 14 | 1.2.2.1 | Define environments |  | 3d | 2004-11-22 | 2004-11-24 |  | 98d |  |  |  |
| 15 | 1.2.2.2 | Assess aggregator requirements |  | 3d | 2004-11-22 | 2004-11-24 |  | 98d |  |  |  |
| 16 | 1.2.2.3 | Assess connectivity mgmt |  | 3d | 2004-11-22 | 2004-11-24 |  | 98d |  |  |  |
| 17 | 1.2.2.4 | Assess DNS requirements |  | 3d | 2004-11-22 | 2004-11-24 |  | 98d |  |  |  |
| 18 | 1.2.2.5 | Assess throughput requirements |  | 3d | 2004-11-22 | 2004-11-24 |  | 16d | 0d |  |  |
| 19 | 1.2.2.6 | Assess environment requirements/impact |  | 2d | 2004-11-25 | 2004-11-26 | 18 | 16d | 0d |  |  |
| 20 | 1.2.2.7 | Update solution document w/requirements & assumptions |  | 2d | 2004-11-29 | 2004-11-30 | 19 | 16d | 0d |  |  |
| 21 | 1.2.2.8 | Conduct connectivity risk analysis |  | 1d | 2004-12-01 | 2004-12-01 | 20 | 16d | 0d |  |  |
| 22 | 1.2.2.9 | Connectivity requirements complete | milestone | 0d | 2004-12-01 | 2004-12-01 | 21 | 16d | 0d |  |  |
| 23 | 1.2.3 | **Partner Prescribing Module Requirements** |  | 14d | 2004-11-22 | 2004-12-09 |  | 0d |  | SSS; Ptnr | 224h |
| 24 | 1.2.3.1 | Document app, general |  | 1d | 2004-11-22 | 2004-11-22 |  | 0d |  |  |  |
| 25 | 1.2.3.2 | Document current workflow |  | 3d | 2004-11-23 | 2004-11-25 | 24 | 0d |  |  |  |
| 26 | 1.2.3.3 | Document admin flow |  | 1d | 2004-11-26 | 2004-11-26 | 25 | 0d |  |  |  |
| 27 | 1.2.3.4 | Identify problem areas |  | 1d | 2004-11-29 | 2004-11-29 | 26 | 0d |  |  |  |
| 28 | 1.2.3.5 | Identify patient attributes |  | 1d | 2004-11-30 | 2004-11-30 | 27 | 0d |  |  |  |
| 29 | 1.2.3.6 | Identify prescriber attributes |  | 1d | 2004-12-01 | 2004-12-01 | 28 | 0d |  |  |  |
| 30 | 1.2.3.7 | Identify pharmacy attributes |  | 1d | 2004-12-02 | 2004-12-02 | 29 | 0d |  |  |  |
| 31 | 1.2.3.8 | Update solution document |  | 2d | 2004-12-03 | 2004-12-06 | 30 | 0d |  |  |  |
| 32 | 1.2.3.9 | Document versions & release plan |  | 3d | 2004-12-07 | 2004-12-09 | 31 | 0d |  |  |  |
| 33 | 1.2.3.10 | Prescribing module requirements & analysis complete | milestone | 0d | 2004-12-09 | 2004-12-09 | 32 | 0d |  |  |  |

| ID | WBS | Task | Type | Duration | Start | Finish | Predecessors | Total slack | Free slack | Resources | Work |
| --- | --- | --- | --- | --- | --- | --- | --- | --- | --- | --- | --- |
| 34 | 1.2.4 | **Partner SCRIPT Interface Requirements** |  | 10d | 2004-12-10 | 2004-12-23 | 33 | 0d |  | SSS; Ptnr | 160h |
| 35 | 1.2.4.1 | Example scenarios review |  | 3d | 2004-12-10 | 2004-12-14 |  | 84d |  |  |  |
| 36 | 1.2.4.2 | Implementation guide review |  | 3d | 2004-12-10 | 2004-12-14 |  | 84d |  |  |  |
| 37 | 1.2.4.3 | Implementation requirements review |  | 3d | 2004-12-10 | 2004-12-14 |  | 0d |  |  |  |
| 38 | 1.2.4.4 | Document messaging attributes |  | 1d | 2004-12-15 | 2004-12-15 | 37 | 0d |  |  |  |
| 39 | 1.2.4.5 | Document intended workflow |  | 2d | 2004-12-16 | 2004-12-17 | 38 | 0d |  |  |  |
| 40 | 1.2.4.6 | Gap analysis for modified messaging flow |  | 2d | 2004-12-20 | 2004-12-21 | 39 | 0d |  |  |  |
| 41 | 1.2.4.7 | Update solution document |  | 2d | 2004-12-22 | 2004-12-23 | 40 | 0d |  |  |  |
| 42 | 1.2.4.8 | SCRIPT interface requirements complete | milestone | 0d | 2004-12-23 | 2004-12-23 | 41 | 0d |  |  |  |
| 43 | 1.2.5 | **Directory Interface Requirements** |  | 4d | 2004-11-22 | 2004-11-25 |  | 42d |  | SSS; Ptnr | 64h |
| 44 | 1.2.5.1 | SPI mapping requirements |  | 2d | 2004-11-22 | 2004-11-23 |  | 99d |  |  |  |
| 45 | 1.2.5.2 | NCPDP mapping requirements |  | 2d | 2004-11-22 | 2004-11-23 |  | 99d |  |  |  |
| 46 | 1.2.5.3 | Service level requirements |  | 2d | 2004-11-22 | 2004-11-23 |  | 42d | 0d |  |  |
| 47 | 1.2.5.4 | Update solution document |  | 2d | 2004-11-24 | 2004-11-25 | 46 | 42d | 0d |  |  |
| 48 | 1.2.5.5 | Directory interface requirements complete | milestone | 0d | 2004-11-25 | 2004-11-25 | 47 | 42d | 4d |  |  |
| 49 | 1.3 | **Design Phase** |  | 29d | 2004-12-02 | 2005-01-11 | 22 | 16d |  |  | 864h |
| 50 | 1.3.1 | **Connectivity Design** |  | 10d | 2004-12-02 | 2004-12-15 | 22 | 19d |  | SSS; Ptnr | 224h |
| 51 | 1.3.1.1 | Document proposed connectivity |  | 1d | 2004-12-02 | 2004-12-02 |  | 19d | 0d |  |  |
| 52 | 1.3.1.2 | Connectivity design approved by network |  | 2d | 2004-12-03 | 2004-12-06 | 51 | 19d | 0d | Ptnr | 16h |
| 53 | 1.3.1.3 | Connectivity design approved by security |  | 3d | 2004-12-07 | 2004-12-09 | 52 | 19d | 0d | Ptnr | 24h |
| 54 | 1.3.1.4 | Connectivity design approved by SureScripts/hoster |  | 3d | 2004-12-10 | 2004-12-14 | 53 | 19d | 0d | SSS | 24h |
| 55 | 1.3.1.5 | Update solution document |  | 1d | 2004-12-15 | 2004-12-15 | 54 | 19d | 0d |  |  |
| 56 | 1.3.1.6 | Connectivity design complete | milestone | 0d | 2004-12-15 | 2004-12-15 | 55 | 19d | 0d |  |  |
| 57 | 1.3.2 | **Partner Prescribing Module Design** |  | 17d | 2004-12-10 | 2005-01-03 | 33 | 52d |  | SSS; Ptnr | 272h |
| 58 | 1.3.2.1 | Create map, module data elements to SCRIPT data elements |  | 5d | 2004-12-10 | 2004-12-16 |  | 82d |  |  |  |
| 59 | 1.3.2.2 | Data element validation, size and value limitation |  | 5d | 2004-12-10 | 2004-12-16 |  | 52d | 0d |  |  |
| 60 | 1.3.2.3 | Patient identification algorithm |  | 3d | 2004-12-17 | 2004-12-21 | 59 | 52d | 0d |  |  |
| 61 | 1.3.2.4 | Prescriber identification algorithm |  | 3d | 2004-12-22 | 2004-12-24 | 60 | 52d | 0d |  |  |
| 62 | 1.3.2.5 | Pharmacy identification algorithm |  | 3d | 2004-12-27 | 2004-12-29 | 61 | 52d | 0d |  |  |
| 63 | 1.3.2.6 | Update solution document |  | 3d | 2004-12-30 | 2005-01-03 | 62 | 52d | 0d |  |  |
| 64 | 1.3.2.7 | Prescribing module design complete | milestone | 0d | 2005-01-03 | 2005-01-03 | 63 | 52d | 6d |  |  |

| ID | WBS | Task | Type | Duration | Start | Finish | Predecessors | Total slack | Free slack | Resources | Work |
| --- | --- | --- | --- | --- | --- | --- | --- | --- | --- | --- | --- |
| 65 | 1.3.3 | **Partner SCRIPT Interface Design** |  | 13d | 2004-12-24 | 2005-01-11 | 42 | 0d |  | SSS; Ptnr | 208h |
| 66 | 1.3.3.1 | Transport design |  | 3d | 2004-12-24 | 2004-12-28 |  | 0d |  |  |  |
| 67 | 1.3.3.2 | Message format/content design (and portal) |  | 6d | 2004-12-29 | 2005-01-05 | 66 | 0d |  |  |  |
| 68 | 1.3.3.3 | Workflow design |  | 3d | 2005-01-06 | 2005-01-10 | 67 | 0d |  |  |  |
| 69 | 1.3.3.4 | Update solution document |  | 1d | 2005-01-11 | 2005-01-11 | 68 | 0d |  |  |  |
| 70 | 1.3.3.5 | SCRIPT interface design complete | milestone | 0d | 2005-01-11 | 2005-01-11 | 69 | 0d |  |  |  |
| 71 | 1.3.4 | **Directory Interface Design** |  | 10d | 2004-12-02 | 2004-12-15 | 48 | 38d |  | SSS; Ptnr | 160h |
| 72 | 1.3.4.1 | SPI mapping design |  | 3d | 2004-12-02 | 2004-12-06 |  | 38d | 0d |  |  |
| 73 | 1.3.4.2 | NCPDP mapping design |  | 2d | 2004-12-07 | 2004-12-08 | 72 | 38d | 0d |  |  |
| 74 | 1.3.4.3 | Service level design |  | 2d | 2004-12-09 | 2004-12-10 | 73 | 38d | 0d |  |  |
| 75 | 1.3.4.4 | Web service methods TBI by partner |  | 2d | 2004-12-13 | 2004-12-14 | 74 | 38d | 0d |  |  |
| 76 | 1.3.4.5 | Update solution document |  | 1d | 2004-12-15 | 2004-12-15 | 75 | 38d | 0d |  |  |
| 77 | 1.3.4.6 | Directory interface design complete | milestone | 0d | 2004-12-15 | 2004-12-15 | 76 | 38d | 0d |  |  |
| 78 | 1.4 | **Build Phase** |  | 54d | 2004-12-16 | 2005-03-01 | 56 | 19d |  |  | 776h |
| 79 | 1.4.1 | Create partner account, Staging |  | 1d | 2004-12-16 | 2004-12-16 | 12 | 82d |  | SSS | 8h |
| 80 | 1.4.2 | Identify/add dev/test users for Admin Console access |  | 1d | 2004-12-16 | 2004-12-16 | 12 | 82d |  | SSS | 8h |
| 81 | 1.4.3 | **Connectivity Build** |  | 5d | 2004-12-16 | 2004-12-22 | 56 | 46d |  | SSS; Ptnr | 80h |
| 82 | 1.4.3.1 | Staging firewall change |  | 5d | 2004-12-16 | 2004-12-22 |  | 77d | 0d |  |  |
| 83 | 1.4.3.2 | Staging encryption setup |  | 2d | 2004-12-16 | 2004-12-17 |  | 81d |  |  |  |
| 84 | 1.4.3.3 | Production firewall change, admin console |  | 5d | 2004-12-16 | 2004-12-22 |  | 78d |  |  |  |
| 85 | 1.4.3.4 | Production firewall change, messaging |  | 5d | 2004-12-16 | 2004-12-22 |  | 46d | 0d |  |  |
| 86 | 1.4.3.5 | Production encryption setup |  | 2d | 2004-12-16 | 2004-12-17 |  | 81d |  |  |  |
| 87 | 1.4.3.6 | Update solution document |  | 1d | 2004-12-16 | 2004-12-16 |  | 82d |  |  |  |
| 88 | 1.4.3.7 | Connectivity build complete | milestone | 0d | 2004-12-22 | 2004-12-22 | 85 | 46d | 0d |  |  |
| 89 | 1.4.4 | Admin Console, User Training |  | 1d | 2004-12-23 | 2004-12-23 | 82 | 77d |  |  |  |

| ID | WBS | Task | Type | Duration | Start | Finish | Predecessors | Total slack | Free slack | Resources | Work |
| --- | --- | --- | --- | --- | --- | --- | --- | --- | --- | --- | --- |
| 90 | 1.4.5 | **Partner Prescribing Module Build** |  | 18d | 2005-01-12 | 2005-02-04 | 70, 64 | 46d |  |  | 160h |
| 91 | 1.4.5.1 | Scheduled drug, route to print or fax |  | 3d | 2005-01-12 | 2005-01-14 |  | 46d | 0d | Ptnr | 24h |
| 92 | 1.4.5.2 | NEWRX creation |  | 3d | 2005-01-17 | 2005-01-19 | 91 | 46d | 0d | Ptnr | 24h |
| 93 | 1.4.5.3 | REFREQ approved, quantity change |  | 2d | 2005-01-20 | 2005-01-21 | 92 | 46d | 0d | Ptnr | 16h |
| 94 | 1.4.5.4 | REFREQ denied, NEWRX to follow |  | 4d | 2005-01-24 | 2005-01-27 | 93 | 46d | 0d | Ptnr | 32h |
| 95 | 1.4.5.5 | Add new user dataflow to web service client |  | 4d | 2005-01-28 | 2005-02-02 | 94 | 46d | 0d | Ptnr | 32h |
| 96 | 1.4.5.6 | Update solution document |  | 2d | 2005-02-03 | 2005-02-04 | 95 | 46d | 0d | SSS; Ptnr | 32h |
| 97 | 1.4.5.7 | Prescribing module build complete | milestone | 0d | 2005-02-04 | 2005-02-04 | 96 | 46d |  |  |  |
| 98 | 1.4.6 | **Partner SCRIPT Interface Build** |  | 35d | 2005-01-12 | 2005-03-01 | 70 | 0d |  |  | 288h |
| 99 | 1.4.6.1 | Server dev |  | 5d | 2005-01-12 | 2005-01-18 |  | 0d |  | Ptnr | 40h |
| 100 | 1.4.6.2 | Client dev |  | 3d | 2005-01-19 | 2005-01-21 | 99 | 0d |  | Ptnr | 24h |
| 101 | 1.4.6.3 | STATUS/ERROR dev |  | 2d | 2005-01-24 | 2005-01-25 | 100 | 0d |  | Ptnr | 16h |
| 102 | 1.4.6.4 | NEWRX dev |  | 7d | 2005-01-26 | 2005-02-03 | 101 | 0d |  | Ptnr | 56h |
| 103 | 1.4.6.5 | REFREQ dev |  | 7d | 2005-02-04 | 2005-02-14 | 102 | 0d |  | Ptnr | 56h |
| 104 | 1.4.6.6 | REFRES dev |  | 7d | 2005-02-15 | 2005-02-23 | 103 | 0d |  | Ptnr | 56h |
| 105 | 1.4.6.7 | VERIFY dev |  | 3d | 2005-02-24 | 2005-02-28 | 104 | 0d |  | Ptnr | 24h |
| 106 | 1.4.6.8 | Update solution document |  | 1d | 2005-03-01 | 2005-03-01 | 105 | 0d |  | SSS; Ptnr | 16h |
| 107 | 1.4.6.9 | SCRIPT interface build complete | milestone | 0d | 2005-03-01 | 2005-03-01 | 106 | 0d |  |  |  |
| 108 | 1.4.7 | **Directory Interface Build** |  | 15d | 2004-12-16 | 2005-01-05 | 77 | 38d |  |  | 232h |
| 109 | 1.4.7.1 | Web service client dev |  | 2d | 2004-12-16 | 2004-12-17 |  | 38d | 0d | Ptnr | 16h |
| 110 | 1.4.7.2 | Download file dev |  | 2d | 2004-12-20 | 2004-12-21 | 109 | 38d | 0d | Ptnr | 16h |
| 111 | 1.4.7.3 | Import download data to system dev |  | 3d | 2004-12-22 | 2004-12-24 | 110 | 38d | 0d | Ptnr | 24h |
| 112 | 1.4.7.4 | Reconcile download data to system dev |  | 7d | 2004-12-27 | 2005-01-04 | 111 | 38d | 0d | Ptnr | 56h |
| 113 | 1.4.7.5 | SPI lookup dev |  | 1d | 2004-12-16 | 2004-12-16 |  | 82d |  | Ptnr | 8h |
| 114 | 1.4.7.6 | NCPDP lookup dev |  | 1d | 2004-12-16 | 2004-12-16 |  | 76d | 0d | Ptnr | 8h |
| 115 | 1.4.7.7 | SPI/NCPDP validation dev |  | 2d | 2004-12-17 | 2004-12-20 | 114 | 76d | 0d | Ptnr | 16h |
| 116 | 1.4.7.8 | Service level lookup dev |  | 2d | 2004-12-21 | 2004-12-22 | 115 | 76d | 0d | Ptnr | 16h |
| 117 | 1.4.7.9 | Service level validation dev |  | 2d | 2004-12-23 | 2004-12-24 | 116 | 76d |  | Ptnr | 16h |
| 118 | 1.4.7.10 | Web service add/update methods |  | 5d | 2004-12-20 | 2004-12-24 | 109 | 76d |  | Ptnr | 40h |
| 119 | 1.4.7.11 | Update solution document |  | 1d | 2005-01-05 | 2005-01-05 | 112 | 38d | 0d | SSS; Ptnr | 16h |
| 120 | 1.4.7.12 | Directory interface build complete | milestone | 0d | 2005-01-05 | 2005-01-05 | 119 | 38d | 0d |  |  |

| ID | WBS | Task | Type | Duration | Start | Finish | Predecessors | Total slack | Free slack | Resources | Work |
| --- | --- | --- | --- | --- | --- | --- | --- | --- | --- | --- | --- |
| 121 | 1.5 | **Test Phase** |  | 70d | 2004-12-23 | 2005-03-30 |  | 8d |  |  | 408h |
| 122 | 1.5.1 | **Connectivity Test** |  | 3d | 2004-12-23 | 2004-12-27 | 88 | 46d |  | SSS; Ptnr | 48h |
| 123 | 1.5.1.1 | Staging firewall connectivity |  | 1d | 2004-12-23 | 2004-12-23 |  | 77d |  |  |  |
| 124 | 1.5.1.2 | Staging application connectivity |  | 1d | 2004-12-23 | 2004-12-23 |  | 77d |  |  |  |
| 125 | 1.5.1.3 | Staging connectivity, application encryption |  | 1d | 2004-12-23 | 2004-12-23 |  | 77d |  |  |  |
| 126 | 1.5.1.4 | Staging connectivity, network encryption |  | 3d | 2004-12-23 | 2004-12-27 |  | 46d | 0d |  |  |
| 127 | 1.5.1.5 | Staging connectivity testing complete | milestone | 0d | 2004-12-27 | 2004-12-27 | 126 | 46d |  |  |  |
| 128 | 1.5.1.6 | Production firewall connectivity |  | 1d | 2004-12-23 | 2004-12-23 |  | 77d |  |  |  |
| 129 | 1.5.1.7 | Production application connectivity |  | 1d | 2004-12-23 | 2004-12-23 |  | 77d |  |  |  |
| 130 | 1.5.1.8 | Production connectivity, application encryption |  | 1d | 2004-12-23 | 2004-12-23 |  | 77d |  |  |  |
| 131 | 1.5.1.9 | Production connectivity, network encryption |  | 3d | 2004-12-23 | 2004-12-27 |  | 73d | 0d |  |  |
| 132 | 1.5.1.10 | Production connectivity testing complete | milestone | 0d | 2004-12-27 | 2004-12-27 | 131 | 73d |  |  |  |
| 133 | 1.5.2 | **Partner SCRIPT Interface Test** |  | 7d | 2005-03-02 | 2005-03-10 | 107, 127 | 0d |  |  | 56h |
| 134 | 1.5.2.1 | Partner system testing |  | 7d | 2005-03-02 | 2005-03-10 |  | 0d |  | Ptnr | 56h |
| 135 | 1.5.2.2 | SCRIPT interface testing complete | milestone | 0d | 2005-03-10 | 2005-03-10 | 134 | 0d |  |  |  |
| 136 | 1.5.3 | **Directory Interface Test** |  | 8d | 2005-01-06 | 2005-01-17 | 120 | 38d |  |  | 64h |
| 137 | 1.5.3.1 | Download file to partner system |  | 1d | 2005-01-06 | 2005-01-06 |  | 38d | 0d | Ptnr | 8h |
| 138 | 1.5.3.2 | Import download data to partner system |  | 2d | 2005-01-07 | 2005-01-10 | 137 | 38d | 0d | Ptnr | 16h |
| 139 | 1.5.3.3 | Download data reconciled successfully |  | 2d | 2005-01-11 | 2005-01-12 | 138 | 38d | 0d | Ptnr | 16h |
| 140 | 1.5.3.4 | Web service add/update entries successfully |  | 1d | 2005-01-13 | 2005-01-13 | 139 | 38d | 0d | Ptnr | 8h |
| 141 | 1.5.3.5 | Admin module add/update user successfully |  | 2d | 2005-01-14 | 2005-01-17 | 140 | 38d | 0d | Ptnr | 16h |
| 142 | 1.5.3.6 | Directory interface testing complete | milestone | 0d | 2005-01-17 | 2005-01-17 | 141 | 38d |  |  |  |
| 143 | 1.5.4 | Pre-Certification testing complete | milestone | 0d | 2005-03-10 | 2005-03-10 | 135, 142 | 0d |  |  |  |
| 144 | 1.5.5 | **Certification** |  | 14d | 2005-03-11 | 2005-03-30 | 143 | 0d |  |  | 240h |
| 145 | 1.5.5.1 | Detailed message review, element use |  | 2d | 2005-03-11 | 2005-03-14 |  | 20d |  | SSS | 16h |
| 146 | 1.5.5.2 | Detailed workflow review, screenshots |  | 2d | 2005-03-11 | 2005-03-14 |  | 0d |  | SSS; Ptnr | 32h |
| 147 | 1.5.5.3 | Config test platform for partner certification |  | 1d | 2005-03-11 | 2005-03-11 |  | 21d |  | SSS | 8h |
| 148 | 1.5.5.4 | NEWRX tests |  | 2d | 2005-03-15 | 2005-03-16 | 146 | 0d |  | SSS; Ptnr | 32h |
| 149 | 1.5.5.5 | REFREQ tests |  | 2d | 2005-03-17 | 2005-03-18 | 148 | 0d |  | SSS; Ptnr | 32h |
| 150 | 1.5.5.6 | REFRES tests |  | 2d | 2005-03-21 | 2005-03-22 | 149 | 0d |  | SSS; Ptnr | 32h |
| 151 | 1.5.5.7 | Scheduled drug test |  | 1d | 2005-03-23 | 2005-03-23 | 150 | 0d |  | SSS; Ptnr | 16h |
| 152 | 1.5.5.8 | Free standing ERROR test |  | 1d | 2005-03-24 | 2005-03-24 | 151 | 0d |  | SSS; Ptnr | 16h |
| 153 | 1.5.5.9 | Failover test, to fax |  | 1d | 2005-03-25 | 2005-03-25 | 152 | 0d |  | SSS; Ptnr | 16h |
| 154 | 1.5.5.10 | Directory web services tests |  | 1d | 2005-03-28 | 2005-03-28 | 153 | 0d |  | SSS; Ptnr | 16h |
| 155 | 1.5.5.11 | Final review of all messages and screenshots |  | 2d | 2005-03-29 | 2005-03-30 | 154 | 0d |  | SSS | 16h |
| 156 | 1.5.5.12 | Partner questionnaire to SureScripts |  | 1d | 2005-03-23 | 2005-03-23 | 150 | 13d |  | Ptnr | 8h |
| 157 | 1.5.5.13 | Certification complete | milestone | 0d | 2005-03-30 | 2005-03-30 | 155 | 0d |  |  |  |

| ID | WBS | Task | Type | Duration | Start | Finish | Predecessors | Total slack | Free slack | Resources | Work |
| --- | --- | --- | --- | --- | --- | --- | --- | --- | --- | --- | --- |
| 158 | 1.6 | **Production Readiness Phase** |  | 8d | 2005-03-31 | 2005-04-11 | 157 | 0d |  |  | 144h |
| 159 | 1.6.1 | **Setup** |  | 7d | 2005-03-31 | 2005-04-08 |  | 0d |  |  | 72h |
| 160 | 1.6.1.1 | Partner SCRIPT interface production deployment |  | 3d | 2005-03-31 | 2005-04-04 |  | 0d |  | Ptnr | 24h |
| 161 | 1.6.1.2 | Partner directory interface production deployment |  | 1d | 2005-04-05 | 2005-04-05 | 160 | 0d |  | Ptnr | 8h |
| 162 | 1.6.1.3 | SureScripts messaging, server setup |  | 1d | 2005-04-06 | 2005-04-06 | 161 | 0d |  | SSS | 8h |
| 163 | 1.6.1.4 | Identify/add support users for Admin Console access |  | 1d | 2005-04-07 | 2005-04-07 | 162 | 0d |  | SSS | 8h |
| 164 | 1.6.1.5 | Initial partner directory data loaded |  | 1d | 2005-04-07 | 2005-04-07 | 162 | 0d |  | Ptnr | 8h |
| 165 | 1.6.1.6 | Reconfirm network connectivity |  | 1d | 2005-04-08 | 2005-04-08 | 164, 132 | 0d |  | SSS; Ptnr | 16h |
| 166 | 1.6.1.7 | Production setup complete | milestone | 0d | 2005-04-08 | 2005-04-08 | 165 | 0d |  |  |  |
| 167 | 1.6.2 | **Support** |  | 8d | 2005-03-31 | 2005-04-11 |  | 0d |  |  | 56h |
| 168 | 1.6.2.1 | Admin Console, User Training |  | 1d | 2005-04-08 | 2005-04-08 | 163 | 0d |  | SSS | 8h |
| 169 | 1.6.2.2 | Brief partner on SureScripts support services |  | 1d | 2005-04-11 | 2005-04-11 | 168 | 0d |  | SSS | 8h |
| 170 | 1.6.2.3 | All partner support email/contacts received |  | 2d | 2005-03-31 | 2005-04-01 |  | 5d | 0d | Ptnr | 16h |
| 171 | 1.6.2.4 | All partner support escalation contacts received |  | 2d | 2005-03-31 | 2005-04-01 |  | 5d | 0d | Ptnr | 16h |
| 172 | 1.6.2.5 | All partner support contacts added to SureScripts Support System |  | 1d | 2005-04-04 | 2005-04-04 | 170, 171 | 5d |  | SSS | 8h |
| 173 | 1.6.3 | Implementation Closeout Meeting |  | 1d | 2005-04-11 | 2005-04-11 | 157, 166 | 0d |  | SSS; Ptnr | 16h |
