# SureScripts Partner Imp 110804

Schedule from MS Project, 2006-01-17 to 2006-06-27, status date 2006-02-02.
mindSHIFT

## Calendars

- Standard: Mon-Fri 08:00-12:00, 13:00-17:00; Sat-Sun off.

## Resources

| Resource |
| --- |
| SSS |
| Ptnr |

## Schedule

| ID | WBS | Task | Type | Duration | Start | Finish | Predecessors | Total slack | Free slack | Constraint | Resources | Work |
| --- | --- | --- | --- | --- | --- | --- | --- | --- | --- | --- | --- | --- |
| 1 | 1 | **Medent- SureScripts Implementation Project** |  | 116d | 2006-01-17 | 2006-06-27 |  | 0d |  |  |  | 2816h |
| 2 | 1.1 | **Initiation Phase** |  | 15d | 2006-01-17 | 2006-02-06 |  | 0d |  |  |  | 32h |
| 3 | 1.1.1 | NDA executed |  | 5d | 2006-01-17 | 2006-01-23 |  | 0d |  | start no earlier than 2006-01-17 |  |  |
| 4 | 1.1.2 | Deliver implementation documentation |  | 1d | 2006-01-24 | 2006-01-24 | 3 | 0d |  |  | SSS | 8h |
| 5 | 1.1.3 | Contract ratified | milestone | 0d | 2006-01-24 | 2006-01-24 | 4 | 0d |  |  |  |  |
| 6 | 1.1.4 | Deliver OLA | milestone | 0d | 2006-01-24 | 2006-01-24 | 5 | 0d |  |  | SSS |  |
| 7 | 1.1.5 | **Project Planning** |  | 9d | 2006-01-25 | 2006-02-06 | 6 | 0d |  |  |  | 24h |
| 8 | 1.1.5.1 | Revise implementation template |  | 5d | 2006-01-25 | 2006-01-31 |  | 0d |  |  |  |  |
| 9 | 1.1.5.2 | Distribute for comment |  | 1d | 2006-02-01 | 2006-02-01 | 8 | 0d |  |  |  |  |
| 10 | 1.1.5.3 | Review/modify plan |  | 3d | 2006-02-02 | 2006-02-06 | 9 | 0d |  |  | SSS | 24h |
| 11 | 1.1.5.4 | Implementation plan complete | milestone | 0d | 2006-02-06 | 2006-02-06 | 10 | 0d |  |  |  |  |
| 12 | 1.2 | **Requirements & Analysis Phase** |  | 24d | 2006-02-07 | 2006-03-10 | 11 | 0d |  |  |  | 592h |
| 13 | 1.2.1 | Initial implementation call |  | 1d | 2006-02-07 | 2006-02-07 |  | 99d | 17d | start no earlier than 2006-02-07 | SSS; Ptnr | 16h |
| 14 | 1.2.2 | **Connectivity Requirements** |  | 8d | 2006-02-07 | 2006-02-16 |  | 16d |  |  | SSS; Ptnr | 128h |
| 15 | 1.2.2.1 | Define environments |  | 3d | 2006-02-07 | 2006-02-09 |  | 98d |  |  |  |  |
| 16 | 1.2.2.2 | Assess aggregator requirements |  | 3d | 2006-02-07 | 2006-02-09 |  | 98d |  |  |  |  |
| 17 | 1.2.2.3 | Assess connectivity mgmt |  | 3d | 2006-02-07 | 2006-02-09 |  | 98d |  |  |  |  |
| 18 | 1.2.2.4 | Assess DNS requirements |  | 3d | 2006-02-07 | 2006-02-09 |  | 98d |  |  |  |  |
| 19 | 1.2.2.5 | Assess throughput requirements |  | 3d | 2006-02-07 | 2006-02-09 |  | 16d | 0d |  |  |  |
| 20 | 1.2.2.6 | Assess environment requirements/impact |  | 2d | 2006-02-10 | 2006-02-13 | 19 | 16d | 0d |  |  |  |
| 21 | 1.2.2.7 | Update solution document w/requirements & assumptions |  | 2d | 2006-02-14 | 2006-02-15 | 20 | 16d | 0d |  |  |  |
| 22 | 1.2.2.8 | Conduct connectivity risk analysis |  | 1d | 2006-02-16 | 2006-02-16 | 21 | 16d | 0d |  |  |  |
| 23 | 1.2.2.9 | Connectivity requirements complete | milestone | 0d | 2006-02-16 | 2006-02-16 | 22 | 16d | 0d |  |  |  |
| 24 | 1.2.3 | **Partner Prescribing Module Requirements** |  | 14d | 2006-02-07 | 2006-02-24 |  | 0d |  |  | SSS; Ptnr | 224h |
| 25 | 1.2.3.1 | Document app, general |  | 1d | 2006-02-07 | 2006-02-07 |  | 0d |  |  |  |  |
| 26 | 1.2.3.2 | Document current workflow |  | 3d | 2006-02-08 | 2006-02-10 | 25 | 0d |  |  |  |  |
| 27 | 1.2.3.3 | Document admin flow |  | 1d | 2006-02-13 | 2006-02-13 | 26 | 0d |  |  |  |  |
| 28 | 1.2.3.4 | Identify problem areas |  | 1d | 2006-02-14 | 2006-02-14 | 27 | 0d |  |  |  |  |
| 29 | 1.2.3.5 | Identify patient attributes |  | 1d | 2006-02-15 | 2006-02-15 | 28 | 0d |  |  |  |  |
| 30 | 1.2.3.6 | Identify prescriber attributes |  | 1d | 2006-02-16 | 2006-02-16 | 29 | 0d |  |  |  |  |
| 31 | 1.2.3.7 | Identify pharmacy attributes |  | 1d | 2006-02-17 | 2006-02-17 | 30 | 0d |  |  |  |  |
| 32 | 1.2.3.8 | Update solution document |  | 2d | 2006-02-20 | 2006-02-21 | 31 | 0d |  |  |  |  |
| 33 | 1.2.3.9 | Document versions & release plan |  | 3d | 2006-02-22 | 2006-02-24 | 32 | 0d |  |  |  |  |
| 34 | 1.2.3.10 | Prescribing module requirements & analysis complete | milestone | 0d | 2006-02-24 | 2006-02-24 | 33 | 0d |  |  |  |  |

| ID | WBS | Task | Type | Duration | Start | Finish | Predecessors | Total slack | Free slack | Resources | Work |
| --- | --- | --- | --- | --- | --- | --- | --- | --- | --- | --- | --- |
| 35 | 1.2.4 | **Partner SCRIPT Interface Requirements** |  | 10d | 2006-02-27 | 2006-03-10 | 34 | 0d |  | SSS; Ptnr | 160h |
| 36 | 1.2.4.1 | Example scenarios review |  | 3d | 2006-02-27 | 2006-03-01 |  | 84d |  |  |  |
| 37 | 1.2.4.2 | Implementation guide review |  | 3d | 2006-02-27 | 2006-03-01 |  | 84d |  |  |  |
| 38 | 1.2.4.3 | Implementation requirements review |  | 3d | 2006-02-27 | 2006-03-01 |  | 0d |  |  |  |
| 39 | 1.2.4.4 | Document messaging attributes |  | 1d | 2006-03-02 | 2006-03-02 | 38 | 0d |  |  |  |
| 40 | 1.2.4.5 | Document intended workflow |  | 2d | 2006-03-03 | 2006-03-06 | 39 | 0d |  |  |  |
| 41 | 1.2.4.6 | Gap analysis for modified messaging flow |  | 2d | 2006-03-07 | 2006-03-08 | 40 | 0d |  |  |  |
| 42 | 1.2.4.7 | Update solution document |  | 2d | 2006-03-09 | 2006-03-10 | 41 | 0d |  |  |  |
| 43 | 1.2.4.8 | SCRIPT interface requirements complete | milestone | 0d | 2006-03-10 | 2006-03-10 | 42 | 0d |  |  |  |
| 44 | 1.2.5 | **Directory Interface Requirements** |  | 4d | 2006-02-07 | 2006-02-10 |  | 42d |  | SSS; Ptnr | 64h |
| 45 | 1.2.5.1 | SPI mapping requirements |  | 2d | 2006-02-07 | 2006-02-08 |  | 99d |  |  |  |
| 46 | 1.2.5.2 | NCPDP mapping requirements |  | 2d | 2006-02-07 | 2006-02-08 |  | 99d |  |  |  |
| 47 | 1.2.5.3 | Service level requirements |  | 2d | 2006-02-07 | 2006-02-08 |  | 42d | 0d |  |  |
| 48 | 1.2.5.4 | Update solution document |  | 2d | 2006-02-09 | 2006-02-10 | 47 | 42d | 0d |  |  |
| 49 | 1.2.5.5 | Directory interface requirements complete | milestone | 0d | 2006-02-10 | 2006-02-10 | 48 | 42d | 4d |  |  |
| 50 | 1.3 | **Design Phase** |  | 29d | 2006-02-17 | 2006-03-29 | 23 | 16d |  |  | 864h |
| 51 | 1.3.1 | **Connectivity Design** |  | 10d | 2006-02-17 | 2006-03-02 | 23 | 19d |  | SSS; Ptnr | 224h |
| 52 | 1.3.1.1 | Document proposed connectivity |  | 1d | 2006-02-17 | 2006-02-17 |  | 19d | 0d |  |  |
| 53 | 1.3.1.2 | Connectivity design approved by network |  | 2d | 2006-02-20 | 2006-02-21 | 52 | 19d | 0d | Ptnr | 16h |
| 54 | 1.3.1.3 | Connectivity design approved by security |  | 3d | 2006-02-22 | 2006-02-24 | 53 | 19d | 0d | Ptnr | 24h |
| 55 | 1.3.1.4 | Connectivity design approved by SureScripts/hoster |  | 3d | 2006-02-27 | 2006-03-01 | 54 | 19d | 0d | SSS | 24h |
| 56 | 1.3.1.5 | Update solution document |  | 1d | 2006-03-02 | 2006-03-02 | 55 | 19d | 0d |  |  |
| 57 | 1.3.1.6 | Connectivity design complete | milestone | 0d | 2006-03-02 | 2006-03-02 | 56 | 19d | 0d |  |  |
| 58 | 1.3.2 | **Partner Prescribing Module Design** |  | 17d | 2006-02-27 | 2006-03-21 | 34 | 52d |  | SSS; Ptnr | 272h |
| 59 | 1.3.2.1 | Create map, module data elements to SCRIPT data elements |  | 5d | 2006-02-27 | 2006-03-03 |  | 82d |  |  |  |
| 60 | 1.3.2.2 | Data element validation, size and value limitation |  | 5d | 2006-02-27 | 2006-03-03 |  | 52d | 0d |  |  |
| 61 | 1.3.2.3 | Patient identification algorithm |  | 3d | 2006-03-06 | 2006-03-08 | 60 | 52d | 0d |  |  |
| 62 | 1.3.2.4 | Prescriber identification algorithm |  | 3d | 2006-03-09 | 2006-03-13 | 61 | 52d | 0d |  |  |
| 63 | 1.3.2.5 | Pharmacy identification algorithm |  | 3d | 2006-03-14 | 2006-03-16 | 62 | 52d | 0d |  |  |
| 64 | 1.3.2.6 | Update solution document |  | 3d | 2006-03-17 | 2006-03-21 | 63 | 52d | 0d |  |  |
| 65 | 1.3.2.7 | Prescribing module design complete | milestone | 0d | 2006-03-21 | 2006-03-21 | 64 | 52d | 6d |  |  |

| ID | WBS | Task | Type | Duration | Start | Finish | Predecessors | Total slack | Free slack | Resources | Work |
| --- | --- | --- | --- | --- | --- | --- | --- | --- | --- | --- | --- |
| 66 | 1.3.3 | **Partner SCRIPT Interface Design** |  | 13d | 2006-03-13 | 2006-03-29 | 43 | 0d |  | SSS; Ptnr | 208h |
| 67 | 1.3.3.1 | Transport design |  | 3d | 2006-03-13 | 2006-03-15 |  | 0d |  |  |  |
| 68 | 1.3.3.2 | Message format/content design (and portal) |  | 6d | 2006-03-16 | 2006-03-23 | 67 | 0d |  |  |  |
| 69 | 1.3.3.3 | Workflow design |  | 3d | 2006-03-24 | 2006-03-28 | 68 | 0d |  |  |  |
| 70 | 1.3.3.4 | Update solution document |  | 1d | 2006-03-29 | 2006-03-29 | 69 | 0d |  |  |  |
| 71 | 1.3.3.5 | SCRIPT interface design complete | milestone | 0d | 2006-03-29 | 2006-03-29 | 70 | 0d |  |  |  |
| 72 | 1.3.4 | **Directory Interface Design** |  | 10d | 2006-02-17 | 2006-03-02 | 49 | 38d |  | SSS; Ptnr | 160h |
| 73 | 1.3.4.1 | SPI mapping design |  | 3d | 2006-02-17 | 2006-02-21 |  | 38d | 0d |  |  |
| 74 | 1.3.4.2 | NCPDP mapping design |  | 2d | 2006-02-22 | 2006-02-23 | 73 | 38d | 0d |  |  |
| 75 | 1.3.4.3 | Service level design |  | 2d | 2006-02-24 | 2006-02-27 | 74 | 38d | 0d |  |  |
| 76 | 1.3.4.4 | Web service methods TBI by partner |  | 2d | 2006-02-28 | 2006-03-01 | 75 | 38d | 0d |  |  |
| 77 | 1.3.4.5 | Update solution document |  | 1d | 2006-03-02 | 2006-03-02 | 76 | 38d | 0d |  |  |
| 78 | 1.3.4.6 | Directory interface design complete | milestone | 0d | 2006-03-02 | 2006-03-02 | 77 | 38d | 0d |  |  |
| 79 | 1.4 | **Build Phase** |  | 54d | 2006-03-03 | 2006-05-17 | 57 | 19d |  |  | 776h |
| 80 | 1.4.1 | Create partner account, Staging |  | 1d | 2006-03-03 | 2006-03-03 | 13 | 82d |  | SSS | 8h |
| 81 | 1.4.2 | Identify/add dev/test users for Admin Console access |  | 1d | 2006-03-03 | 2006-03-03 | 13 | 82d |  | SSS | 8h |
| 82 | 1.4.3 | **Connectivity Build** |  | 5d | 2006-03-03 | 2006-03-09 | 57 | 46d |  | SSS; Ptnr | 80h |
| 83 | 1.4.3.1 | Staging firewall change |  | 5d | 2006-03-03 | 2006-03-09 |  | 77d | 0d |  |  |
| 84 | 1.4.3.2 | Staging encryption setup |  | 2d | 2006-03-03 | 2006-03-06 |  | 81d |  |  |  |
| 85 | 1.4.3.3 | Production firewall change, admin console |  | 5d | 2006-03-03 | 2006-03-09 |  | 78d |  |  |  |
| 86 | 1.4.3.4 | Production firewall change, messaging |  | 5d | 2006-03-03 | 2006-03-09 |  | 46d | 0d |  |  |
| 87 | 1.4.3.5 | Production encryption setup |  | 2d | 2006-03-03 | 2006-03-06 |  | 81d |  |  |  |
| 88 | 1.4.3.6 | Update solution document |  | 1d | 2006-03-03 | 2006-03-03 |  | 82d |  |  |  |
| 89 | 1.4.3.7 | Connectivity build complete | milestone | 0d | 2006-03-09 | 2006-03-09 | 86 | 46d | 0d |  |  |
| 90 | 1.4.4 | Admin Console, User Training |  | 1d | 2006-03-10 | 2006-03-10 | 83 | 77d |  |  |  |

| ID | WBS | Task | Type | Duration | Start | Finish | Predecessors | Total slack | Free slack | Resources | Work |
| --- | --- | --- | --- | --- | --- | --- | --- | --- | --- | --- | --- |
| 91 | 1.4.5 | **Partner Prescribing Module Build** |  | 18d | 2006-03-30 | 2006-04-24 | 71, 65 | 46d |  |  | 160h |
| 92 | 1.4.5.1 | DEA Scheduled drug, route to print or fax |  | 3d | 2006-03-30 | 2006-04-03 |  | 46d | 0d | Ptnr | 24h |
| 93 | 1.4.5.2 | NEWRX creation |  | 3d | 2006-04-04 | 2006-04-06 | 92 | 46d | 0d | Ptnr | 24h |
| 94 | 1.4.5.3 | REFREQ approved, quantity change |  | 2d | 2006-04-07 | 2006-04-10 | 93 | 46d | 0d | Ptnr | 16h |
| 95 | 1.4.5.4 | REFREQ denied, NEWRX to follow |  | 4d | 2006-04-11 | 2006-04-14 | 94 | 46d | 0d | Ptnr | 32h |
| 96 | 1.4.5.5 | Add new user dataflow to web service client |  | 4d | 2006-04-17 | 2006-04-20 | 95 | 46d | 0d | Ptnr | 32h |
| 97 | 1.4.5.6 | Update solution document |  | 2d | 2006-04-21 | 2006-04-24 | 96 | 46d | 0d | SSS; Ptnr | 32h |
| 98 | 1.4.5.7 | Prescribing module build complete | milestone | 0d | 2006-04-24 | 2006-04-24 | 97 | 46d |  |  |  |
| 99 | 1.4.6 | **Partner SCRIPT Interface Build** |  | 35d | 2006-03-30 | 2006-05-17 | 71 | 0d |  |  | 288h |
| 100 | 1.4.6.1 | Server dev |  | 5d | 2006-03-30 | 2006-04-05 |  | 0d |  | Ptnr | 40h |
| 101 | 1.4.6.2 | Client dev |  | 3d | 2006-04-06 | 2006-04-10 | 100 | 0d |  | Ptnr | 24h |
| 102 | 1.4.6.3 | STATUS/ERROR dev |  | 2d | 2006-04-11 | 2006-04-12 | 101 | 0d |  | Ptnr | 16h |
| 103 | 1.4.6.4 | NEWRX dev |  | 7d | 2006-04-13 | 2006-04-21 | 102 | 0d |  | Ptnr | 56h |
| 104 | 1.4.6.5 | REFREQ dev |  | 7d | 2006-04-24 | 2006-05-02 | 103 | 0d |  | Ptnr | 56h |
| 105 | 1.4.6.6 | REFRES dev |  | 7d | 2006-05-03 | 2006-05-11 | 104 | 0d |  | Ptnr | 56h |
| 106 | 1.4.6.7 | VERIFY dev |  | 3d | 2006-05-12 | 2006-05-16 | 105 | 0d |  | Ptnr | 24h |
| 107 | 1.4.6.8 | Update solution document |  | 1d | 2006-05-17 | 2006-05-17 | 106 | 0d |  | SSS; Ptnr | 16h |
| 108 | 1.4.6.9 | SCRIPT interface build complete | milestone | 0d | 2006-05-17 | 2006-05-17 | 107 | 0d |  |  |  |
| 109 | 1.4.7 | **Directory Interface Build** |  | 15d | 2006-03-03 | 2006-03-23 | 78 | 38d |  |  | 232h |
| 110 | 1.4.7.1 | Web service client dev |  | 2d | 2006-03-03 | 2006-03-06 |  | 38d | 0d | Ptnr | 16h |
| 111 | 1.4.7.2 | Download file dev |  | 2d | 2006-03-07 | 2006-03-08 | 110 | 38d | 0d | Ptnr | 16h |
| 112 | 1.4.7.3 | Import download data to system dev |  | 3d | 2006-03-09 | 2006-03-13 | 111 | 38d | 0d | Ptnr | 24h |
| 113 | 1.4.7.4 | Reconcile download data to system dev |  | 7d | 2006-03-14 | 2006-03-22 | 112 | 38d | 0d | Ptnr | 56h |
| 114 | 1.4.7.5 | SPI lookup dev |  | 1d | 2006-03-03 | 2006-03-03 |  | 82d |  | Ptnr | 8h |
| 115 | 1.4.7.6 | NCPDP lookup dev |  | 1d | 2006-03-03 | 2006-03-03 |  | 76d | 0d | Ptnr | 8h |
| 116 | 1.4.7.7 | SPI/NCPDP validation dev |  | 2d | 2006-03-06 | 2006-03-07 | 115 | 76d | 0d | Ptnr | 16h |
| 117 | 1.4.7.8 | Service level lookup dev |  | 2d | 2006-03-08 | 2006-03-09 | 116 | 76d | 0d | Ptnr | 16h |
| 118 | 1.4.7.9 | Service level validation dev |  | 2d | 2006-03-10 | 2006-03-13 | 117 | 76d |  | Ptnr | 16h |
| 119 | 1.4.7.10 | Web service add/update methods |  | 5d | 2006-03-07 | 2006-03-13 | 110 | 76d |  | Ptnr | 40h |
| 120 | 1.4.7.11 | Update solution document |  | 1d | 2006-03-23 | 2006-03-23 | 113 | 38d | 0d | SSS; Ptnr | 16h |
| 121 | 1.4.7.12 | Directory interface build complete | milestone | 0d | 2006-03-23 | 2006-03-23 | 120 | 38d | 0d |  |  |

| ID | WBS | Task | Type | Duration | Start | Finish | Predecessors | Total slack | Free slack | Resources | Work |
| --- | --- | --- | --- | --- | --- | --- | --- | --- | --- | --- | --- |
| 122 | 1.5 | **Test Phase** |  | 70d | 2006-03-10 | 2006-06-15 |  | 8d |  |  | 408h |
| 123 | 1.5.1 | **Connectivity Test** |  | 3d | 2006-03-10 | 2006-03-14 | 89 | 46d |  | SSS; Ptnr | 48h |
| 124 | 1.5.1.1 | Staging firewall connectivity |  | 1d | 2006-03-10 | 2006-03-10 |  | 77d |  |  |  |
| 125 | 1.5.1.2 | Staging application connectivity |  | 1d | 2006-03-10 | 2006-03-10 |  | 77d |  |  |  |
| 126 | 1.5.1.3 | Staging connectivity, application encryption |  | 1d | 2006-03-10 | 2006-03-10 |  | 77d |  |  |  |
| 127 | 1.5.1.4 | Staging connectivity, network encryption |  | 3d | 2006-03-10 | 2006-03-14 |  | 46d | 0d |  |  |
| 128 | 1.5.1.5 | Staging connectivity testing complete | milestone | 0d | 2006-03-14 | 2006-03-14 | 127 | 46d |  |  |  |
| 129 | 1.5.1.6 | Production firewall connectivity |  | 1d | 2006-03-10 | 2006-03-10 |  | 77d |  |  |  |
| 130 | 1.5.1.7 | Production application connectivity |  | 1d | 2006-03-10 | 2006-03-10 |  | 77d |  |  |  |
| 131 | 1.5.1.8 | Production connectivity, application encryption |  | 1d | 2006-03-10 | 2006-03-10 |  | 77d |  |  |  |
| 132 | 1.5.1.9 | Production connectivity, network encryption |  | 3d | 2006-03-10 | 2006-03-14 |  | 73d | 0d |  |  |
| 133 | 1.5.1.10 | Production connectivity testing complete | milestone | 0d | 2006-03-14 | 2006-03-14 | 132 | 73d |  |  |  |
| 134 | 1.5.2 | **Partner SCRIPT Interface Test** |  | 7d | 2006-05-18 | 2006-05-26 | 108, 128 | 0d |  |  | 56h |
| 135 | 1.5.2.1 | Partner system testing |  | 7d | 2006-05-18 | 2006-05-26 |  | 0d |  | Ptnr | 56h |
| 136 | 1.5.2.2 | SCRIPT interface testing complete | milestone | 0d | 2006-05-26 | 2006-05-26 | 135 | 0d |  |  |  |
| 137 | 1.5.3 | **Directory Interface Test** |  | 8d | 2006-03-24 | 2006-04-04 | 121 | 38d |  |  | 64h |
| 138 | 1.5.3.1 | Download file to partner system |  | 1d | 2006-03-24 | 2006-03-24 |  | 38d | 0d | Ptnr | 8h |
| 139 | 1.5.3.2 | Import download data to partner system |  | 2d | 2006-03-27 | 2006-03-28 | 138 | 38d | 0d | Ptnr | 16h |
| 140 | 1.5.3.3 | Download data reconciled successfully |  | 2d | 2006-03-29 | 2006-03-30 | 139 | 38d | 0d | Ptnr | 16h |
| 141 | 1.5.3.4 | Web service add/update entries successfully |  | 1d | 2006-03-31 | 2006-03-31 | 140 | 38d | 0d | Ptnr | 8h |
| 142 | 1.5.3.5 | Admin module add/update user successfully |  | 2d | 2006-04-03 | 2006-04-04 | 141 | 38d | 0d | Ptnr | 16h |
| 143 | 1.5.3.6 | Directory interface testing complete | milestone | 0d | 2006-04-04 | 2006-04-04 | 142 | 38d |  |  |  |
| 144 | 1.5.4 | Pre-Certification testing complete | milestone | 0d | 2006-05-26 | 2006-05-26 | 136, 143 | 0d |  |  |  |
| 145 | 1.5.5 | OLA Executed | milestone | 0d | 2006-05-26 | 2006-05-26 | 144 | 0d |  |  |  |

| ID | WBS | Task | Type | Duration | Start | Finish | Predecessors | Total slack | Free slack | Resources | Work |
| --- | --- | --- | --- | --- | --- | --- | --- | --- | --- | --- | --- |
| 146 | 1.5.6 | **Certification** |  | 14d | 2006-05-29 | 2006-06-15 |  | 0d |  |  | 240h |
| 147 | 1.5.6.1 | Detailed message review, element use |  | 2d | 2006-05-29 | 2006-05-30 | 145 | 20d |  | SSS | 16h |
| 148 | 1.5.6.2 | Detailed workflow review, screenshots |  | 2d | 2006-05-29 | 2006-05-30 | 145 | 0d |  | SSS; Ptnr | 32h |
| 149 | 1.5.6.3 | Config test platform for partner certification |  | 1d | 2006-05-29 | 2006-05-29 | 145 | 21d |  | SSS | 8h |
| 150 | 1.5.6.4 | NEWRX tests |  | 2d | 2006-05-31 | 2006-06-01 | 148 | 0d |  | SSS; Ptnr | 32h |
| 151 | 1.5.6.5 | REFREQ tests |  | 2d | 2006-06-02 | 2006-06-05 | 150 | 0d |  | SSS; Ptnr | 32h |
| 152 | 1.5.6.6 | REFRES tests |  | 2d | 2006-06-06 | 2006-06-07 | 151 | 0d |  | SSS; Ptnr | 32h |
| 153 | 1.5.6.7 | Scheduled drug test |  | 1d | 2006-06-08 | 2006-06-08 | 152 | 0d |  | SSS; Ptnr | 16h |
| 154 | 1.5.6.8 | Free standing ERROR test |  | 1d | 2006-06-09 | 2006-06-09 | 153 | 0d |  | SSS; Ptnr | 16h |
| 155 | 1.5.6.9 | Failover test, to fax |  | 1d | 2006-06-12 | 2006-06-12 | 154 | 0d |  | SSS; Ptnr | 16h |
| 156 | 1.5.6.10 | Directory web services tests |  | 1d | 2006-06-13 | 2006-06-13 | 155 | 0d |  | SSS; Ptnr | 16h |
| 157 | 1.5.6.11 | Final review of all messages and screenshots |  | 2d | 2006-06-14 | 2006-06-15 | 156 | 0d |  | SSS | 16h |
| 158 | 1.5.6.12 | Partner questionnaire to SureScripts |  | 1d | 2006-06-08 | 2006-06-08 | 152 | 13d |  | Ptnr | 8h |
| 159 | 1.5.6.13 | Certification complete | milestone | 0d | 2006-06-15 | 2006-06-15 | 157 | 0d |  |  |  |
| 160 | 1.6 | **Production Readiness Phase** |  | 8d | 2006-06-16 | 2006-06-27 | 159 | 0d |  |  | 144h |
| 161 | 1.6.1 | **Setup** |  | 7d | 2006-06-16 | 2006-06-26 |  | 0d |  |  | 72h |
| 162 | 1.6.1.1 | Partner SCRIPT interface production deployment |  | 3d | 2006-06-16 | 2006-06-20 |  | 0d |  | Ptnr | 24h |
| 163 | 1.6.1.2 | Partner directory interface production deployment |  | 1d | 2006-06-21 | 2006-06-21 | 162 | 0d |  | Ptnr | 8h |
| 164 | 1.6.1.3 | SureScripts messaging, server setup |  | 1d | 2006-06-22 | 2006-06-22 | 163 | 0d |  | SSS | 8h |
| 165 | 1.6.1.4 | Identify/add support users for Admin Console access |  | 1d | 2006-06-23 | 2006-06-23 | 164 | 0d |  | SSS | 8h |
| 166 | 1.6.1.5 | Initial partner directory data loaded |  | 1d | 2006-06-23 | 2006-06-23 | 164 | 0d |  | Ptnr | 8h |
| 167 | 1.6.1.6 | Reconfirm network connectivity |  | 1d | 2006-06-26 | 2006-06-26 | 166, 133 | 0d |  | SSS; Ptnr | 16h |
| 168 | 1.6.1.7 | Production setup complete | milestone | 0d | 2006-06-26 | 2006-06-26 | 167 | 0d |  |  |  |
| 169 | 1.6.2 | **Support** |  | 8d | 2006-06-16 | 2006-06-27 |  | 0d |  |  | 56h |
| 170 | 1.6.2.1 | Admin Console, User Training |  | 1d | 2006-06-26 | 2006-06-26 | 165 | 0d |  | SSS | 8h |
| 171 | 1.6.2.2 | Brief partner on SureScripts support services |  | 1d | 2006-06-27 | 2006-06-27 | 170 | 0d |  | SSS | 8h |
| 172 | 1.6.2.3 | All partner support email/contacts received |  | 2d | 2006-06-16 | 2006-06-19 |  | 5d | 0d | Ptnr | 16h |
| 173 | 1.6.2.4 | All partner support escalation contacts received |  | 2d | 2006-06-16 | 2006-06-19 |  | 5d | 0d | Ptnr | 16h |
| 174 | 1.6.2.5 | All partner support contacts added to SureScripts Support System |  | 1d | 2006-06-20 | 2006-06-20 | 172, 173 | 5d |  | SSS | 8h |
| 175 | 1.6.3 | Implementation Closeout Meeting |  | 1d | 2006-06-27 | 2006-06-27 | 159, 168 | 0d |  | SSS; Ptnr | 16h |
