# SureScripts Partner Imp 110804

Schedule from MS Project, 2006-01-17 to 2006-05-11, status date 2006-02-02, A marks actual dates.
mindSHIFT

## Calendars

- Standard: Mon-Fri 08:00-12:00, 13:00-17:00; Sat-Sun off.

## Resources

| Resource |
| --- |
| SSS |
| Ptnr |

## Schedule

| ID | WBS | Task | Type | Duration | Start | Finish | Predecessors | Complete | Remaining | Total slack | Free slack | Constraint | Resources | Work | Actual work |
| --- | --- | --- | --- | --- | --- | --- | --- | --- | --- | --- | --- | --- | --- | --- | --- |
| 1 | 1 | **Medent- SureScripts Implementation Project** |  | 83d? | 2006-01-17 A | 2006-05-11 |  | 7% | 76.96d? | 0d |  |  |  | 1968h | 32h |
| 2 | 1.1 | **Initiation Phase** |  | 15d | 2006-01-17 A | 2006-02-06 A |  | 100% |  |  |  |  |  | 32h | 32h |
| 3 | 1.1.1 | NDA executed |  | 5d | 2006-01-17 A | 2006-01-23 A |  | 100% |  |  |  | start no earlier than 2006-01-17 |  |  |  |
| 4 | 1.1.2 | Deliver implementation documentation |  | 1d | 2006-01-24 A | 2006-01-24 A | 3 | 100% |  |  |  |  | SSS | 8h | 8h |
| 5 | 1.1.3 | Contract ratified | milestone | 0d | 2006-01-24 A | 2006-01-24 A | 4 | 100% |  |  |  |  |  |  |  |
| 6 | 1.1.4 | Deliver OLA | milestone | 0d | 2006-01-24 A | 2006-01-24 A | 5 | 100% |  |  |  |  | SSS |  |  |
| 7 | 1.1.5 | **Project Planning** |  | 9d | 2006-01-25 A | 2006-02-06 A | 6 | 100% |  |  |  |  |  | 24h | 24h |
| 8 | 1.1.5.1 | Revise implementation template |  | 5d | 2006-01-25 A | 2006-01-31 A |  | 100% |  |  |  |  |  |  |  |
| 9 | 1.1.5.2 | Distribute for comment |  | 1d | 2006-02-01 A | 2006-02-01 A | 8 | 100% |  |  |  |  |  |  |  |
| 10 | 1.1.5.3 | Review/modify plan |  | 3d | 2006-02-02 A | 2006-02-06 A | 9 | 100% |  |  |  |  | SSS | 24h | 24h |
| 11 | 1.1.5.4 | Implementation plan complete | milestone | 0d | 2006-02-06 A | 2006-02-06 A | 10 | 100% |  |  |  |  |  |  |  |
| 12 | 1.2 | **Requirements & Analysis Phase** |  | 13d | 2006-02-07 | 2006-02-23 | 11 |  |  | 0d |  |  |  | 352h |  |
| 13 | 1.2.1 | Initial implementation call |  | 1d | 2006-02-07 | 2006-02-07 |  |  |  | 99d | 17d | start no earlier than 2006-02-07 | SSS; Ptnr | 16h |  |
| 14 | 1.2.2 | **Connectivity Requirements** |  | 4d | 2006-02-07 | 2006-02-10 |  |  |  | 7d |  |  | SSS; Ptnr | 64h |  |
| 15 | 1.2.2.1 | Define environments |  | 1d | 2006-02-07 | 2006-02-07 |  |  |  | 67d |  |  |  |  |  |
| 16 | 1.2.2.2 | Assess aggregator requirements |  | 1d | 2006-02-07 | 2006-02-07 |  |  |  | 67d |  |  |  |  |  |
| 17 | 1.2.2.3 | Assess connectivity mgmt |  | 1d | 2006-02-07 | 2006-02-07 |  |  |  | 67d |  |  |  |  |  |
| 18 | 1.2.2.4 | Assess DNS requirements |  | 1d | 2006-02-07 | 2006-02-07 |  |  |  | 67d |  |  |  |  |  |
| 19 | 1.2.2.5 | Assess throughput requirements |  | 1d | 2006-02-07 | 2006-02-07 |  |  |  | 7d | 0d |  |  |  |  |
| 20 | 1.2.2.6 | Assess environment requirements/impact |  | 1d | 2006-02-08 | 2006-02-08 | 19 |  |  | 7d | 0d |  |  |  |  |
| 21 | 1.2.2.7 | Update solution document w/requirements & assumptions |  | 1d | 2006-02-09 | 2006-02-09 | 20 |  |  | 7d | 0d |  |  |  |  |
| 22 | 1.2.2.8 | Conduct connectivity risk analysis |  | 1d | 2006-02-10 | 2006-02-10 | 21 |  |  | 7d | 0d |  |  |  |  |
| 23 | 1.2.2.9 | Connectivity requirements complete | milestone | 0d | 2006-02-10 | 2006-02-10 | 22 |  |  | 7d | 0d |  |  |  |  |
| 24 | 1.2.3 | **Partner Prescribing Module Requirements** |  | 8d | 2006-02-07 | 2006-02-16 |  |  |  | 0d |  |  | SSS; Ptnr | 128h |  |
| 25 | 1.2.3.1 | Document app, general |  | 1d | 2006-02-07 | 2006-02-07 |  |  |  | 0d |  |  |  |  |  |
| 26 | 1.2.3.2 | Document current workflow |  | 1d | 2006-02-08 | 2006-02-08 | 25 |  |  | 0d |  |  |  |  |  |
| 27 | 1.2.3.3 | Document admin flow |  | 1d | 2006-02-09 | 2006-02-09 | 26 |  |  | 0d |  |  |  |  |  |
| 28 | 1.2.3.4 | Identify problem areas |  | 1d | 2006-02-10 | 2006-02-10 | 27 |  |  | 0d |  |  |  |  |  |
| 29 | 1.2.3.5 | Identify patient attributes |  | 1d | 2006-02-13 | 2006-02-13 | 28 |  |  | 0d |  |  |  |  |  |
| 30 | 1.2.3.6 | Identify prescriber attributes |  | 1d | 2006-02-14 | 2006-02-14 | 29 |  |  | 0d |  |  |  |  |  |
| 31 | 1.2.3.7 | Identify pharmacy attributes |  | 1d | 2006-02-15 | 2006-02-15 | 30 |  |  | 0d |  |  |  |  |  |
| 32 | 1.2.3.8 | Update solution document |  | 1d | 2006-02-16 | 2006-02-16 | 31 |  |  | 0d |  |  |  |  |  |
| 33 | 1.2.3.9 | Document versions & release plan | milestone | 0d | 2006-02-16 | 2006-02-16 | 32 |  |  | 0d |  |  |  |  |  |
| 34 | 1.2.3.10 | Prescribing module requirements & analysis complete | milestone | 0d | 2006-02-16 | 2006-02-16 | 33 |  |  | 0d |  |  |  |  |  |

| ID | WBS | Task | Type | Duration | Start | Finish | Predecessors | Total slack | Free slack | Resources | Work |
| --- | --- | --- | --- | --- | --- | --- | --- | --- | --- | --- | --- |
| 35 | 1.2.4 | **Partner SCRIPT Interface Requirements** |  | 5d | 2006-02-17 | 2006-02-23 | 34 | 0d |  | SSS; Ptnr | 80h |
| 36 | 1.2.4.1 | Example scenarios review |  | 1d | 2006-02-17 | 2006-02-17 |  | 59d |  |  |  |
| 37 | 1.2.4.2 | Implementation guide review |  | 1d | 2006-02-17 | 2006-02-17 |  | 59d |  |  |  |
| 38 | 1.2.4.3 | Implementation requirements review |  | 1d | 2006-02-17 | 2006-02-17 |  | 0d |  |  |  |
| 39 | 1.2.4.4 | Document messaging attributes |  | 1d | 2006-02-20 | 2006-02-20 | 38 | 0d |  |  |  |
| 40 | 1.2.4.5 | Document intended workflow |  | 1d | 2006-02-21 | 2006-02-21 | 39 | 0d |  |  |  |
| 41 | 1.2.4.6 | Gap analysis for modified messaging flow |  | 1d | 2006-02-22 | 2006-02-22 | 40 | 0d |  |  |  |
| 42 | 1.2.4.7 | Update solution document |  | 1d | 2006-02-23 | 2006-02-23 | 41 | 0d |  |  |  |
| 43 | 1.2.4.8 | SCRIPT interface requirements complete | milestone | 0d | 2006-02-23 | 2006-02-23 | 42 | 0d |  |  |  |
| 44 | 1.2.5 | **Directory Interface Requirements** |  | 4d | 2006-02-07 | 2006-02-10 |  | 20d |  | SSS; Ptnr | 64h |
| 45 | 1.2.5.1 | SPI mapping requirements |  | 2d | 2006-02-07 | 2006-02-08 |  | 99d |  |  |  |
| 46 | 1.2.5.2 | NCPDP mapping requirements |  | 2d | 2006-02-07 | 2006-02-08 |  | 99d |  |  |  |
| 47 | 1.2.5.3 | Service level requirements |  | 2d | 2006-02-07 | 2006-02-08 |  | 42d | 0d |  |  |
| 48 | 1.2.5.4 | Update solution document |  | 2d | 2006-02-09 | 2006-02-10 | 47 | 42d | 0d |  |  |
| 49 | 1.2.5.5 | Directory interface requirements complete | milestone | 0d | 2006-02-10 | 2006-02-10 | 48 | 42d | 4d |  |  |
| 50 | 1.3 | **Design Phase** |  | 17d? | 2006-02-13 | 2006-03-07 | 23 | 7d |  |  | 560h |
| 51 | 1.3.1 | **Connectivity Design** |  | 10d | 2006-02-13 | 2006-02-24 | 23 | 7d |  | SSS; Ptnr | 224h |
| 52 | 1.3.1.1 | Document proposed connectivity |  | 1d | 2006-02-13 | 2006-02-13 |  | 7d | 0d |  |  |
| 53 | 1.3.1.2 | Connectivity design approved by network |  | 2d | 2006-02-14 | 2006-02-15 | 52 | 7d | 0d | Ptnr | 16h |
| 54 | 1.3.1.3 | Connectivity design approved by security |  | 3d | 2006-02-16 | 2006-02-20 | 53 | 7d | 0d | Ptnr | 24h |
| 55 | 1.3.1.4 | Connectivity design approved by SureScripts/hoster |  | 3d | 2006-02-21 | 2006-02-23 | 54 | 7d | 0d | SSS | 24h |
| 56 | 1.3.1.5 | Update solution document |  | 1d | 2006-02-24 | 2006-02-24 | 55 | 7d | 0d |  |  |
| 57 | 1.3.1.6 | Connectivity design complete | milestone | 0d | 2006-02-24 | 2006-02-24 | 56 | 7d | 0d |  |  |
| 58 | 1.3.2 | **Partner Prescribing Module Design** |  | 7d | 2006-02-17 | 2006-02-27 | 34 | 41d |  | SSS; Ptnr | 112h |
| 59 | 1.3.2.1 | Create map, module data elements to SCRIPT data elements |  | 2d | 2006-02-17 | 2006-02-20 |  | 58d |  |  |  |
| 60 | 1.3.2.2 | Data element validation, size and value limitation |  | 2d | 2006-02-17 | 2006-02-20 |  | 41d | 0d |  |  |
| 61 | 1.3.2.3 | Patient identification algorithm |  | 1d | 2006-02-21 | 2006-02-21 | 60 | 41d | 0d |  |  |
| 62 | 1.3.2.4 | Prescriber identification algorithm |  | 1d | 2006-02-22 | 2006-02-22 | 61 | 41d | 0d |  |  |
| 63 | 1.3.2.5 | Pharmacy identification algorithm |  | 2d | 2006-02-23 | 2006-02-24 | 62 | 41d | 0d |  |  |
| 64 | 1.3.2.6 | Update solution document |  | 1d | 2006-02-27 | 2006-02-27 | 63 | 41d | 0d |  |  |
| 65 | 1.3.2.7 | Prescribing module design complete | milestone | 0d | 2006-02-27 | 2006-02-27 | 64 | 41d | 6d |  |  |

| ID | WBS | Task | Type | Duration | Start | Finish | Predecessors | Total slack | Free slack | Resources | Work |
| --- | --- | --- | --- | --- | --- | --- | --- | --- | --- | --- | --- |
| 66 | 1.3.3 | **Partner SCRIPT Interface Design** |  | 8d | 2006-02-24 | 2006-03-07 | 43 | 0d |  | SSS; Ptnr | 128h |
| 67 | 1.3.3.1 | Transport design |  | 1d | 2006-02-24 | 2006-02-24 |  | 0d |  |  |  |
| 68 | 1.3.3.2 | Message format/content design (and portal) |  | 4d | 2006-02-27 | 2006-03-02 | 67 | 0d |  |  |  |
| 69 | 1.3.3.3 | Workflow design |  | 2d | 2006-03-03 | 2006-03-06 | 68 | 0d |  |  |  |
| 70 | 1.3.3.4 | Update solution document |  | 1d | 2006-03-07 | 2006-03-07 | 69 | 0d |  |  |  |
| 71 | 1.3.3.5 | SCRIPT interface design complete | milestone | 0d | 2006-03-07 | 2006-03-07 | 70 | 0d |  |  |  |
| 72 | 1.3.4 | **Directory Interface Design** |  | 6d? | 2006-02-13 | 2006-02-20 | 49 | 20d |  | SSS; Ptnr | 96h |
| 73 | 1.3.4.1 | SPI mapping design |  | 2d | 2006-02-13 | 2006-02-14 |  | 20d | 0d |  |  |
| 74 | 1.3.4.2 | NCPDP mapping design |  | 1d | 2006-02-15 | 2006-02-15 | 73 | 20d | 0d |  |  |
| 75 | 1.3.4.3 | Service level design |  | 1d | 2006-02-16 | 2006-02-16 | 74 | 20d | 0d |  |  |
| 76 | 1.3.4.4 | Web service methods TBI by partner |  | 1d? | 2006-02-17 | 2006-02-17 | 75 | 20d | 0d |  |  |
| 77 | 1.3.4.5 | Update solution document |  | 1d | 2006-02-20 | 2006-02-20 | 76 | 20d | 0d |  |  |
| 78 | 1.3.4.6 | Directory interface design complete | milestone | 0d | 2006-02-20 | 2006-02-20 | 77 | 20d | 4d |  |  |
| 79 | 1.4 | **Build Phase** |  | 28d | 2006-02-27 | 2006-04-05 | 57 | 7d |  |  | 528h |
| 80 | 1.4.1 | Create partner account, Staging |  | 1d | 2006-02-27 | 2006-02-27 | 13 | 53d |  | SSS | 8h |
| 81 | 1.4.2 | Identify/add dev/test users for Admin Console access |  | 1d | 2006-02-27 | 2006-02-27 | 13 | 53d |  | SSS | 8h |
| 82 | 1.4.3 | **Connectivity Build** |  | 3d | 2006-02-27 | 2006-03-01 | 57 | 23d |  | SSS; Ptnr | 48h |
| 83 | 1.4.3.1 | Staging firewall change |  | 3d | 2006-02-27 | 2006-03-01 |  | 50d | 0d |  |  |
| 84 | 1.4.3.2 | Staging encryption setup |  | 2d | 2006-02-27 | 2006-02-28 |  | 52d |  |  |  |
| 85 | 1.4.3.3 | Production firewall change, admin console |  | 3d | 2006-02-27 | 2006-03-01 |  | 51d |  |  |  |
| 86 | 1.4.3.4 | Production firewall change, messaging |  | 3d | 2006-02-27 | 2006-03-01 |  | 23d | 0d |  |  |
| 87 | 1.4.3.5 | Production encryption setup |  | 2d | 2006-02-27 | 2006-02-28 |  | 52d |  |  |  |
| 88 | 1.4.3.6 | Update solution document |  | 1d | 2006-02-27 | 2006-02-27 |  | 53d |  |  |  |
| 89 | 1.4.3.7 | Connectivity build complete | milestone | 0d | 2006-03-01 | 2006-03-01 | 86 | 23d | 0d |  |  |
| 90 | 1.4.4 | Admin Console, User Training |  | 1d | 2006-03-02 | 2006-03-02 | 83 | 50d |  |  |  |

| ID | WBS | Task | Type | Duration | Start | Finish | Predecessors | Total slack | Free slack | Resources | Work |
| --- | --- | --- | --- | --- | --- | --- | --- | --- | --- | --- | --- |
| 91 | 1.4.5 | **Partner Prescribing Module Build** |  | 12d | 2006-03-08 | 2006-03-23 | 71, 65 | 35d |  |  | 104h |
| 92 | 1.4.5.1 | DEA Scheduled drug, route to print or fax |  | 1d | 2006-03-08 | 2006-03-08 |  | 35d | 0d | Ptnr | 8h |
| 93 | 1.4.5.2 | NEWRX creation |  | 2d | 2006-03-09 | 2006-03-10 | 92 | 35d | 0d | Ptnr | 16h |
| 94 | 1.4.5.3 | REFREQ approved, quantity change |  | 2d | 2006-03-13 | 2006-03-14 | 93 | 35d | 0d | Ptnr | 16h |
| 95 | 1.4.5.4 | REFREQ denied, NEWRX to follow |  | 3d | 2006-03-15 | 2006-03-17 | 94 | 35d | 0d | Ptnr | 24h |
| 96 | 1.4.5.5 | Add new user dataflow to web service client |  | 3d | 2006-03-20 | 2006-03-22 | 95 | 35d | 0d | Ptnr | 24h |
| 97 | 1.4.5.6 | Update solution document |  | 1d | 2006-03-23 | 2006-03-23 | 96 | 35d | 0d | SSS; Ptnr | 16h |
| 98 | 1.4.5.7 | Prescribing module build complete | milestone | 0d | 2006-03-23 | 2006-03-23 | 97 | 35d |  |  |  |
| 99 | 1.4.6 | **Partner SCRIPT Interface Build** |  | 21d | 2006-03-08 | 2006-04-05 | 71 | 0d |  |  | 176h |
| 100 | 1.4.6.1 | Server dev |  | 3d | 2006-03-08 | 2006-03-10 |  | 0d |  | Ptnr | 24h |
| 101 | 1.4.6.2 | Client dev |  | 2d | 2006-03-13 | 2006-03-14 | 100 | 0d |  | Ptnr | 16h |
| 102 | 1.4.6.3 | STATUS/ERROR dev |  | 1d | 2006-03-15 | 2006-03-15 | 101 | 0d |  | Ptnr | 8h |
| 103 | 1.4.6.4 | NEWRX dev |  | 4d | 2006-03-16 | 2006-03-21 | 102 | 0d |  | Ptnr | 32h |
| 104 | 1.4.6.5 | REFREQ dev |  | 4d | 2006-03-22 | 2006-03-27 | 103 | 0d |  | Ptnr | 32h |
| 105 | 1.4.6.6 | REFRES dev |  | 4d | 2006-03-28 | 2006-03-31 | 104 | 0d |  | Ptnr | 32h |
| 106 | 1.4.6.7 | VERIFY dev |  | 2d | 2006-04-03 | 2006-04-04 | 105 | 0d |  | Ptnr | 16h |
| 107 | 1.4.6.8 | Update solution document |  | 1d | 2006-04-05 | 2006-04-05 | 106 | 0d |  | SSS; Ptnr | 16h |
| 108 | 1.4.6.9 | SCRIPT interface build complete | milestone | 0d | 2006-04-05 | 2006-04-05 | 107 | 0d |  |  |  |
| 109 | 1.4.7 | **Directory Interface Build** |  | 11d | 2006-02-27 | 2006-03-13 | 78 | 16d |  |  | 184h |
| 110 | 1.4.7.1 | Web service client dev |  | 2d | 2006-02-27 | 2006-02-28 |  | 16d | 0d | Ptnr | 16h |
| 111 | 1.4.7.2 | Download file dev |  | 2d | 2006-03-01 | 2006-03-02 | 110 | 16d | 0d | Ptnr | 16h |
| 112 | 1.4.7.3 | Import download data to system dev |  | 2d | 2006-03-03 | 2006-03-06 | 111 | 16d | 0d | Ptnr | 16h |
| 113 | 1.4.7.4 | Reconcile download data to system dev |  | 4d | 2006-03-07 | 2006-03-10 | 112 | 16d | 0d | Ptnr | 32h |
| 114 | 1.4.7.5 | SPI lookup dev |  | 1d | 2006-02-27 | 2006-02-27 |  | 53d |  | Ptnr | 8h |
| 115 | 1.4.7.6 | NCPDP lookup dev |  | 1d | 2006-02-27 | 2006-02-27 |  | 47d | 0d | Ptnr | 8h |
| 116 | 1.4.7.7 | SPI/NCPDP validation dev |  | 2d | 2006-02-28 | 2006-03-01 | 115 | 47d | 0d | Ptnr | 16h |
| 117 | 1.4.7.8 | Service level lookup dev |  | 2d | 2006-03-02 | 2006-03-03 | 116 | 47d | 0d | Ptnr | 16h |
| 118 | 1.4.7.9 | Service level validation dev |  | 2d | 2006-03-06 | 2006-03-07 | 117 | 47d |  | Ptnr | 16h |
| 119 | 1.4.7.10 | Web service add/update methods |  | 3d | 2006-03-01 | 2006-03-03 | 110 | 49d |  | Ptnr | 24h |
| 120 | 1.4.7.11 | Update solution document |  | 1d | 2006-03-13 | 2006-03-13 | 113 | 16d | 0d | SSS; Ptnr | 16h |
| 121 | 1.4.7.12 | Directory interface build complete | milestone | 0d | 2006-03-13 | 2006-03-13 | 120 | 16d | 0d |  |  |

| ID | WBS | Task | Type | Duration | Start | Finish | Predecessors | Total slack | Free slack | Resources | Work |
| --- | --- | --- | --- | --- | --- | --- | --- | --- | --- | --- | --- |
| 122 | 1.5 | **Test Phase** |  | 44d | 2006-03-02 | 2006-05-02 |  | 7d |  |  | 360h |
| 123 | 1.5.1 | **Connectivity Test** |  | 2d | 2006-03-02 | 2006-03-03 | 89 | 23d |  | SSS; Ptnr | 32h |
| 124 | 1.5.1.1 | Staging firewall connectivity |  | 1d | 2006-03-02 | 2006-03-02 |  | 50d |  |  |  |
| 125 | 1.5.1.2 | Staging application connectivity |  | 1d | 2006-03-02 | 2006-03-02 |  | 50d |  |  |  |
| 126 | 1.5.1.3 | Staging connectivity, application encryption |  | 1d | 2006-03-02 | 2006-03-02 |  | 50d |  |  |  |
| 127 | 1.5.1.4 | Staging connectivity, network encryption |  | 2d | 2006-03-02 | 2006-03-03 |  | 23d | 0d |  |  |
| 128 | 1.5.1.5 | Staging connectivity testing complete | milestone | 0d | 2006-03-03 | 2006-03-03 | 127 | 23d |  |  |  |
| 129 | 1.5.1.6 | Production firewall connectivity |  | 1d | 2006-03-02 | 2006-03-02 |  | 50d |  |  |  |
| 130 | 1.5.1.7 | Production application connectivity |  | 1d | 2006-03-02 | 2006-03-02 |  | 50d |  |  |  |
| 131 | 1.5.1.8 | Production connectivity, application encryption |  | 1d | 2006-03-02 | 2006-03-02 |  | 50d |  |  |  |
| 132 | 1.5.1.9 | Production connectivity, network encryption |  | 2d | 2006-03-02 | 2006-03-03 |  | 47d | 0d |  |  |
| 133 | 1.5.1.10 | Production connectivity testing complete | milestone | 0d | 2006-03-03 | 2006-03-03 | 132 | 47d |  |  |  |
| 134 | 1.5.2 | **Partner SCRIPT Interface Test** |  | 5d | 2006-04-06 | 2006-04-12 | 108, 128 | 0d |  |  | 40h |
| 135 | 1.5.2.1 | Partner system testing |  | 5d | 2006-04-06 | 2006-04-12 |  | 0d |  | Ptnr | 40h |
| 136 | 1.5.2.2 | SCRIPT interface testing complete | milestone | 0d | 2006-04-12 | 2006-04-12 | 135 | 0d |  |  |  |
| 137 | 1.5.3 | **Directory Interface Test** |  | 6d | 2006-03-14 | 2006-03-21 | 121 | 16d |  |  | 48h |
| 138 | 1.5.3.1 | Download file to partner system |  | 1d | 2006-03-14 | 2006-03-14 |  | 16d | 0d | Ptnr | 8h |
| 139 | 1.5.3.2 | Import download data to partner system |  | 2d | 2006-03-15 | 2006-03-16 | 138 | 16d | 0d | Ptnr | 16h |
| 140 | 1.5.3.3 | Download data reconciled successfully |  | 1d | 2006-03-17 | 2006-03-17 | 139 | 16d | 0d | Ptnr | 8h |
| 141 | 1.5.3.4 | Web service add/update entries successfully |  | 1d | 2006-03-20 | 2006-03-20 | 140 | 16d | 0d | Ptnr | 8h |
| 142 | 1.5.3.5 | Admin module add/update user successfully |  | 1d | 2006-03-21 | 2006-03-21 | 141 | 16d | 0d | Ptnr | 8h |
| 143 | 1.5.3.6 | Directory interface testing complete | milestone | 0d | 2006-03-21 | 2006-03-21 | 142 | 16d |  |  |  |
| 144 | 1.5.4 | Pre-Certification testing complete | milestone | 0d | 2006-04-12 | 2006-04-12 | 136, 143 | 0d |  |  |  |
| 145 | 1.5.5 | OLA Executed | milestone | 0d | 2006-04-12 | 2006-04-12 | 144 | 0d |  |  |  |

| ID | WBS | Task | Type | Duration | Start | Finish | Predecessors | Total slack | Free slack | Resources | Work |
| --- | --- | --- | --- | --- | --- | --- | --- | --- | --- | --- | --- |
| 146 | 1.5.6 | **Certification** |  | 14d | 2006-04-13 | 2006-05-02 |  | 0d |  |  | 240h |
| 147 | 1.5.6.1 | Detailed message review, element use |  | 2d | 2006-04-13 | 2006-04-14 | 145 | 19d |  | SSS | 16h |
| 148 | 1.5.6.2 | Detailed workflow review, screenshots |  | 2d | 2006-04-13 | 2006-04-14 | 145 | 0d |  | SSS; Ptnr | 32h |
| 149 | 1.5.6.3 | Config test platform for partner certification |  | 1d | 2006-04-13 | 2006-04-13 | 145 | 20d |  | SSS | 8h |
| 150 | 1.5.6.4 | NEWRX tests |  | 2d | 2006-04-17 | 2006-04-18 | 148 | 0d |  | SSS; Ptnr | 32h |
| 151 | 1.5.6.5 | REFREQ tests |  | 2d | 2006-04-19 | 2006-04-20 | 150 | 0d |  | SSS; Ptnr | 32h |
| 152 | 1.5.6.6 | REFRES tests |  | 2d | 2006-04-21 | 2006-04-24 | 151 | 0d |  | SSS; Ptnr | 32h |
| 153 | 1.5.6.7 | Scheduled drug test |  | 1d | 2006-04-25 | 2006-04-25 | 152 | 0d |  | SSS; Ptnr | 16h |
| 154 | 1.5.6.8 | Free standing ERROR test |  | 1d | 2006-04-26 | 2006-04-26 | 153 | 0d |  | SSS; Ptnr | 16h |
| 155 | 1.5.6.9 | Failover test, to fax |  | 1d | 2006-04-27 | 2006-04-27 | 154 | 0d |  | SSS; Ptnr | 16h |
| 156 | 1.5.6.10 | Directory web services tests |  | 1d | 2006-04-28 | 2006-04-28 | 155 | 0d |  | SSS; Ptnr | 16h |
| 157 | 1.5.6.11 | Final review of all messages and screenshots |  | 2d | 2006-05-01 | 2006-05-02 | 156 | 0d |  | SSS | 16h |
| 158 | 1.5.6.12 | Partner questionnaire to SureScripts |  | 1d | 2006-04-25 | 2006-04-25 | 152 | 12d |  | Ptnr | 8h |
| 159 | 1.5.6.13 | Certification complete | milestone | 0d | 2006-05-02 | 2006-05-02 | 157 | 0d |  |  |  |
| 160 | 1.6 | **Production Readiness Phase** |  | 7d | 2006-05-03 | 2006-05-11 | 159 | 0d |  |  | 136h |
| 161 | 1.6.1 | **Setup** |  | 6d | 2006-05-03 | 2006-05-10 |  | 0d |  |  | 64h |
| 162 | 1.6.1.1 | Partner SCRIPT interface production deployment |  | 2d | 2006-05-03 | 2006-05-04 |  | 0d |  | Ptnr | 16h |
| 163 | 1.6.1.2 | Partner directory interface production deployment |  | 1d | 2006-05-05 | 2006-05-05 | 162 | 0d |  | Ptnr | 8h |
| 164 | 1.6.1.3 | SureScripts messaging, server setup |  | 1d | 2006-05-08 | 2006-05-08 | 163 | 0d |  | SSS | 8h |
| 165 | 1.6.1.4 | Identify/add support users for Admin Console access |  | 1d | 2006-05-09 | 2006-05-09 | 164 | 0d |  | SSS | 8h |
| 166 | 1.6.1.5 | Initial partner directory data loaded |  | 1d | 2006-05-09 | 2006-05-09 | 164 | 0d |  | Ptnr | 8h |
| 167 | 1.6.1.6 | Reconfirm network connectivity |  | 1d | 2006-05-10 | 2006-05-10 | 166, 133 | 0d |  | SSS; Ptnr | 16h |
| 168 | 1.6.1.7 | Production setup complete | milestone | 0d | 2006-05-10 | 2006-05-10 | 167 | 0d |  |  |  |
| 169 | 1.6.2 | **Support** |  | 7d | 2006-05-03 | 2006-05-11 |  | 0d |  |  | 56h |
| 170 | 1.6.2.1 | Admin Console, User Training |  | 1d | 2006-05-10 | 2006-05-10 | 165 | 0d |  | SSS | 8h |
| 171 | 1.6.2.2 | Brief partner on SureScripts support services |  | 1d | 2006-05-11 | 2006-05-11 | 170 | 0d |  | SSS | 8h |
| 172 | 1.6.2.3 | All partner support email/contacts received |  | 2d | 2006-05-03 | 2006-05-04 |  | 4d | 0d | Ptnr | 16h |
| 173 | 1.6.2.4 | All partner support escalation contacts received |  | 2d | 2006-05-03 | 2006-05-04 |  | 4d | 0d | Ptnr | 16h |
| 174 | 1.6.2.5 | All partner support contacts added to SureScripts Support System |  | 1d | 2006-05-05 | 2006-05-05 | 172, 173 | 4d |  | SSS | 8h |
| 175 | 1.6.3 | Implementation Closeout Meeting |  | 1d | 2006-05-11 | 2006-05-11 | 159, 168 | 0d |  | SSS; Ptnr | 16h |
